# SERVICIO DE HABILITACIÓN DE ACCESOS Y PLATAFORMAS, Y MOVIMIENTO DE TIERRAS II PARTE - CUENCA HUAURA

Schedule from Primavera P6, 2023-03-10 to 2023-12-30, data date 2023-03-10.

## Calendars

- Dos turnos - 6x1 - 10 horas: Mon-Sat 01:00-06:00, 07:00-12:00, 13:00-18:00, 19:00-00:00; Sun off. Exceptions (off unless hours are given): 2023-04-06 to 2023-04-07, 2023-05-01, 2023-06-29, 2023-07-28 to 2023-07-29, 2023-08-30, 2023-11-01, 2023-12-08, 2023-12-25.

## Schedule

| ID | WBS | Activity | Type | Duration | Start | Finish | Predecessors | Total float | Free float |
| --- | --- | --- | --- | --- | --- | --- | --- | --- | --- |
|  | 1 | **Hitos** |  |  | 2023-03-10 | 2023-12-20 |  |  |  |
| A1000 |  | Suscripción del contrato | milestone | 0d | 2023-03-10 | 2023-03-10 |  | 0d |  |
| A1010 |  | Inicio de obra - Acceso al Sitio | milestone | 0d | 2023-04-01 | 2023-04-01 | A1000 FS+19d | 0d |  |
| A1020 |  | Inicio de Habilitación y mejoramiento de accesos | milestone | 0d | 2023-04-11 | 2023-04-11 | A1160 SS+3d | 1d | 0d |
| A1030 |  | Inicio de Movimiento de Tierras - Diques Paquete 2 | milestone | 0d | 2023-04-21 | 2023-04-21 | A1130 SS+6d | 2d | 0d |
| A1050 |  | Inicio de Movimiento de Tierras - Diques Paquete 3 | milestone | 0d | 2023-06-01 | 2023-06-01 | A1010 FS+49d | 0d |  |
| A1040 |  | Culminación de Diques Paquete 2 | milestone | 0d | 2023-10-03 | 2023-10-03 | A1180, A1190, A1200, A1210, A1220, A1230, A1240, A1250, A1260, A1270, A1280, A1290, A1300, A1310, A1320, A1330, A1340, A1345, A1350, A1355, A1360, A1370, A1380, A1385, A1390, A1400, A1410, A1470, A1420, A1430, A1440, A1450, A1500, A1505, A1510, A1515, A1520, A1530, A1540, A1545, A1550, A1560, A1570, A1630, A1580, A1590, A1600, A1610, A1660, A1665, A1670, A1675, A1680, A1690, A1700, A1710, A1720, A1730, A1705, A1790, A1740, A1750, A1770, A1760, A3520 | 65d |  |
| A1060 |  | Culminación de Diques Paquete 3 | milestone | 0d | 2023-12-20 | 2023-12-20 | A1800, A1805, A1810, A1815, A1820, A1830, A1840, A1845, A1850, A1860, A1870, A1930, A1880, A1890, A1900, A1910, A1940, A1945, A1950, A1955, A1960, A1970, A1980, A1985, A1990, A2000, A2010, A2070, A2020, A2030, A2040, A2050, A2100, A2105, A2110, A2115, A2120, A2130, A2140, A2145, A2150, A2160, A2170, A2230, A2180, A2190, A2200, A2210, A2260, A2265, A2270, A2275, A2280, A2290, A2300, A2305, A2310, A2320, A2330, A2390, A2340, A2350, A2360, A2370, A2420, A2425, A2430, A2435, A2440, A2450, A2460, A2465, A2470, A2480, A2490, A2550, A2500, A2510, A2520, A2530, A2580, A2585, A2590, A2595, A2600, A2610, A2620, A2625, A2630, A2640, A2650, A2710, A2660, A2670, A2680, A2690, A2740, A2745, A2750, A2755, A2760, A2770, A2780, A2785, A2790, A2800, A2810, A2870, A2820, A2830, A2840, A2850, A2900, A2905, A2910, A2915, A2920, A2930, A2940, A2945, A2950, A2960, A2970, A3030, A2980, A2990, A3000, A3010, A3060, A3065, A3070, A3075, A3080, A3090, A3100, A3105, A3110, A3120, A3130, A3190, A3140, A3150, A3160, A3170, A3220, A3225, A3230, A3235, A3240, A3250, A3260, A3265, A3270, A3280, A3290, A3350, A3300, A3310, A3320, A3330, A3380, A3385, A3390, A3395, A3400, A3410, A3420, A3425, A3430, A3440, A3450, A3510, A3460, A3470, A3480, A3490, A3530, A3550 | 0d |  |
|  | 2 | **Obras Provisionales** |  |  | 2023-04-01 | 2023-12-30 |  |  |  |
| A1070 |  | Movilización |  | 26d | 2023-04-01 | 2023-05-05 | A1010 | 1d | 0d |
| A1080 |  | Mejoramiento y habilitación de caminos de acceso |  | 32d | 2023-04-11 | 2023-05-19 | A1020 | 1d | 0d |
| A1090 |  | Limpieza manual de material vegetal y de residuos |  | 32d | 2023-04-11 | 2023-05-19 | A1080 SS | 178d |  |
| A1100 |  | Tubería HDPE corrugada 630 mm |  | 32d | 2023-04-11 | 2023-05-19 | A1080 SS | 178d |  |
| A1110 |  | Tubería HDPE corrugada 1000 mm |  | 32d | 2023-04-11 | 2023-05-19 | A1080 SS | 178d |  |
| A1120 |  | Habilitación de plataformas |  | 26d | 2023-04-14 | 2023-05-16 | A1130 SS | 181d |  |
| A1130 |  | Campamento Provisional de Obra |  | 26d | 2023-04-14 | 2023-05-16 | A1080 SS+3d | 2d | 0d |
| A1140 |  | Mantenimiento de caminos de acceso |  | 177d | 2023-05-19 | 2023-12-19 | A1080 | 1d |  |
| A1150 |  | Desmovilización |  | 8d | 2023-12-20 | 2023-12-30 | A1140, A1060, A1090, A1100, A1110, A1120, A1170, A1040, A3560, A3570 | 0d |  |
|  | 3 | **Topografía** |  |  | 2023-04-05 | 2023-12-19 |  |  |  |
| A1160 |  | Trazo y replanteo inicial |  | 26d | 2023-04-05 | 2023-05-09 | A1070 SS+3d | 1d | 0d |
| A1170 |  | Trazo y replanteo durante la obra |  | 186d | 2023-05-09 | 2023-12-19 | A1160 | 1d |  |
|  | 4 | **Paquete 2** |  |  | 2023-04-21 | 2023-10-03 |  |  |  |
|  | 1 | **DI-PR-12-I** |  |  | 2023-04-21 | 2023-09-07 |  |  |  |
|  | 1 | **Excavaciones** |  |  | 2023-04-21 | 2023-07-18 |  |  |  |
| A1180 |  | Desbroce |  | 71d | 2023-04-21 | 2023-07-15 | A1030 | 2d | 0d |
| A1190 |  | Excavación de cimentación |  | 71d | 2023-04-21 | 2023-07-15 | A1180 SS | 2d | 0d |
| A1200 |  | Remoción Dique Existente |  | 71d | 2023-04-21 | 2023-07-15 | A1190 SS | 102d | 0d |
| A1210 |  | Excavación localizada - sobrexcavación |  | 71d | 2023-04-21 | 2023-07-15 | A1190 SS | 102d | 0d |
| A1220 |  | Perfilado y conformación de plataforma de fundación |  | 70d | 2023-04-25 | 2023-07-18 | A1190 SS+3d | 104d | 1d |
| A1230 |  | Excavación de uña |  | 67d | 2023-04-28 | 2023-07-18 | A1190 SS+6d | 6d | 0d |

| ID | WBS | Activity | Duration | Start | Finish | Predecessors | Total float | Free float |
| --- | --- | --- | --- | --- | --- | --- | --- | --- |
|  | 2 | **Rellenos** |  | 2023-05-06 | 2023-09-07 |  |  |  |
| A1240 |  | Relleno con material granular | 60d | 2023-05-06 | 2023-07-16 | A1230 SS+6d | 10d | 0d |
| A1250 |  | Relleno con material seleccionado en sobreexcavación | 60d | 2023-05-06 | 2023-07-16 | A1240 SS | 97d | 8d |
| A1260 |  | Perfilado de Talud del dique | 50d | 2023-05-20 | 2023-07-19 | A1240 SS+12d | 91d | 0d |
| A1270 |  | Relleno sin compactar | 35d | 2023-07-25 | 2023-09-07 | A1320 | 72d | 0d |
| A1290 |  | Grava para drenaje | 6d | 2023-07-25 | 2023-08-03 | A1270 SS, A1240 | 116d | 51d |
| A1280 |  | Relleno afirmado | 10d | 2023-07-27 | 2023-08-10 | A1330 | 103d | 23d |
|  | 3 | **Geotextil** |  | 2023-05-03 | 2023-07-20 |  |  |  |
| A1300 |  | Instalación de Geotextil - uña | 65d | 2023-05-03 | 2023-07-19 | A1230 SS+3d | 72d | 0d |
| A1310 |  | Instalación de Geotextil - Talud | 45d | 2023-05-27 | 2023-07-20 | A1260 SS+6d | 96d | 0d |
|  | 4 | **Colocación de Roca** |  | 2023-05-06 | 2023-07-27 |  |  |  |
| A1320 |  | Colocación de roca de uña | 67d | 2023-05-06 | 2023-07-25 | A1300 SS+3d | 72d | 0d |
| A1330 |  | Colocación de roca de talud | 48d | 2023-05-31 | 2023-07-27 | A1310 SS+3d | 98d | 0d |
|  | 2 | **DI-PR-13-D** |  | 2023-07-15 | 2023-09-17 |  |  |  |
|  | 1 | **Excavaciones** |  | 2023-07-15 | 2023-08-13 |  |  |  |
| A1340 |  | Desbroce | 18d | 2023-07-15 | 2023-08-08 | A1180 | 2d | 0d |
| A1345 |  | Excavación de cimentación | 18d | 2023-07-15 | 2023-08-08 | A1340 SS, A1190 | 2d | 0d |
| A1350 |  | Remoción Dique Existente | 18d | 2023-07-15 | 2023-08-08 | A1345 SS, A1200 | 102d | 0d |
| A1355 |  | Excavación localizada - sobrexcavación | 18d | 2023-07-15 | 2023-08-08 | A1345 SS, A1210 | 102d | 0d |
| A1360 |  | Perfilado y conformación de plataforma de fundación | 16d | 2023-07-19 | 2023-08-09 | A1345 SS+3d, A1220 | 103d | 2d |
| A1370 |  | Excavación de uña | 17d | 2023-07-22 | 2023-08-13 | A1345 SS+6d, A1230 | 2d | 0d |
|  | 2 | **Rellenos** |  | 2023-07-26 | 2023-09-17 |  |  |  |
| A1380 |  | Relleno con material granular | 23d | 2023-07-26 | 2023-08-24 | A1370 SS+3d, A1240 | 2d | 0d |
| A1385 |  | Relleno con material seleccionado en sobreexcavación | 23d | 2023-07-26 | 2023-08-24 | A1380 SS, A1250 | 89d | 0d |
| A1390 |  | Perfilado de Talud del dique | 12d | 2023-08-11 | 2023-08-25 | A1380 SS+12d, A1260 | 73d | 0d |
| A1400 |  | Relleno sin compactar | 9d | 2023-09-07 | 2023-09-17 | A1440, A1270 | 72d | 0d |
| A1410 |  | Relleno afirmado | 3d | 2023-09-07 | 2023-09-10 | A1450, A1280 | 80d | 12d |
| A1470 |  | Grava para drenaje | 2d | 2023-09-07 | 2023-09-09 | A1380, A1400 SS | 85d | 20d |

| ID | WBS | Activity | Duration | Start | Finish | Predecessors | Total float | Free float |
| --- | --- | --- | --- | --- | --- | --- | --- | --- |
|  | 3 | **Geotextil** |  | 2023-07-26 | 2023-09-06 |  |  |  |
| A1420 |  | Instalación de Geotextil - uña | 15d | 2023-07-26 | 2023-08-15 | A1370 SS+3d, A1300 | 86d | 0d |
| A1430 |  | Instalación de Geotextil - Talud | 15d | 2023-08-18 | 2023-09-06 | A1390 SS+6d, A1310 | 73d | 0d |
|  | 4 | **Colocación de Roca** |  | 2023-08-01 | 2023-09-07 |  |  |  |
| A1440 |  | Colocación de roca de uña | 17d | 2023-08-01 | 2023-08-20 | A1420 SS+3d, A1320 | 86d | 1d |
| A1450 |  | Colocación de roca de talud | 13d | 2023-08-22 | 2023-09-07 | A1430 SS+3d, A1330 | 78d | 0d |
|  | 3 | **DE-PR-24-D** |  | 2023-08-08 | 2023-09-27 |  |  |  |
|  | 1 | **Excavaciones** |  | 2023-08-08 | 2023-08-23 |  |  |  |
| A1500 |  | Desbroce | 7d | 2023-08-08 | 2023-08-16 | A1340 | 70d | 0d |
| A1505 |  | Excavación de cimentación | 7d | 2023-08-08 | 2023-08-16 | A1500 SS, A1345 | 70d | 0d |
| A1510 |  | Remoción Dique Existente | 7d | 2023-08-08 | 2023-08-16 | A1505 SS, A1350 | 102d | 0d |
| A1515 |  | Excavación localizada - sobrexcavación | 7d | 2023-08-08 | 2023-08-16 | A1505 SS, A1355 | 102d | 0d |
| A1520 |  | Perfilado y conformación de plataforma de fundación | 5d | 2023-08-11 | 2023-08-17 | A1505 SS+3d, A1360 | 101d | 2d |
| A1530 |  | Excavación de uña | 7d | 2023-08-15 | 2023-08-23 | A1505 SS+6d, A1370 | 70d | 0d |
|  | 2 | **Rellenos** |  | 2023-08-24 | 2023-09-27 |  |  |  |
| A1540 |  | Relleno con material granular | 7d | 2023-08-24 | 2023-09-02 | A1530 SS+3d, A1380 | 65d | 0d |
| A1545 |  | Relleno con material seleccionado en sobreexcavación | 7d | 2023-08-24 | 2023-09-02 | A1540 SS, A1385 | 89d | 0d |
| A1550 |  | Perfilado de Talud del dique | 4d | 2023-09-08 | 2023-09-13 | A1540 SS+12d, A1390 | 65d | 0d |
| A1560 |  | Relleno sin compactar | 4d | 2023-09-18 | 2023-09-22 | A1600, A1400 | 72d | 0d |
| A1630 |  | Grava para drenaje | 2d | 2023-09-18 | 2023-09-20 | A1560 SS, A1540 | 76d | 11d |
| A1570 |  | Relleno afirmado | 2d | 2023-09-25 | 2023-09-27 | A1610, A1410 | 68d | 3d |
|  | 3 | **Geotextil** |  | 2023-08-18 | 2023-09-24 |  |  |  |
| A1580 |  | Instalación de Geotextil - uña | 5d | 2023-08-18 | 2023-08-24 | A1530 SS+3d, A1420 | 87d | 0d |
| A1590 |  | Instalación de Geotextil - Talud | 8d | 2023-09-15 | 2023-09-24 | A1550 SS+6d, A1430 | 65d | 0d |

| ID | WBS | Activity | Duration | Start | Finish | Predecessors | Total float | Free float |
| --- | --- | --- | --- | --- | --- | --- | --- | --- |
|  | 4 | **Colocación de Roca** |  | 2023-08-22 | 2023-09-24 |  |  |  |
| A1600 |  | Colocación de roca de uña | 7d | 2023-08-22 | 2023-08-30 | A1580 SS+3d, A1440 | 87d | 0d |
| A1610 |  | Colocación de roca de talud | 5d | 2023-09-19 | 2023-09-24 | A1590 SS+3d, A1450 | 68d | 0d |
|  | 4 | **DI-PR-25-I** |  | 2023-08-16 | 2023-10-03 |  |  |  |
|  | 1 | **Excavaciones** |  | 2023-08-16 | 2023-08-26 |  |  |  |
| A1660 |  | Desbroce | 3d | 2023-08-16 | 2023-08-19 | A1500 | 71d | 0d |
| A1665 |  | Excavación de cimentación | 3d | 2023-08-16 | 2023-08-19 | A1660 SS, A1505 | 71d | 0d |
| A1670 |  | Remoción Dique Existente | 3d | 2023-08-16 | 2023-08-19 | A1665 SS, A1510 | 102d | 37d |
| A1675 |  | Excavación localizada - sobrexcavación | 3d | 2023-08-16 | 2023-08-19 | A1665 SS, A1515 | 102d | 37d |
| A1680 |  | Perfilado y conformación de plataforma de fundación | 3d | 2023-08-19 | 2023-08-23 | A1665 SS+3d, A1520 | 99d | 34d |
| A1690 |  | Excavación de uña | 3d | 2023-08-23 | 2023-08-26 | A1665 SS+6d, A1530 | 71d | 0d |
|  | 2 | **Rellenos** |  | 2023-09-02 | 2023-10-03 |  |  |  |
| A1700 |  | Relleno con material granular | 2d | 2023-09-02 | 2023-09-05 | A1690 SS+3d, A1540 | 66d | 0d |
| A1705 |  | Relleno con material seleccionado en sobreexcavación | 2d | 2023-09-02 | 2023-09-05 | A1700 SS, A1545 | 89d | 24d |
| A1710 |  | Perfilado de Talud del dique | 2d | 2023-09-16 | 2023-09-19 | A1700 SS+12d, A1550 | 66d | 1d |
| A1720 |  | Relleno sin compactar | 2d | 2023-09-22 | 2023-09-24 | A1760, A1560 | 72d | 0d |
| A1790 |  | Grava para drenaje | 2d | 2023-09-22 | 2023-09-24 | A1720 SS, A1700 | 72d | 7d |
| A1730 |  | Relleno afirmado | 2d | 2023-09-30 | 2023-10-03 | A1770, A1570 | 65d | 0d |
|  | 3 | **Geotextil** |  | 2023-08-26 | 2023-09-27 |  |  |  |
| A1740 |  | Instalación de Geotextil - uña | 2d | 2023-08-26 | 2023-08-29 | A1690 SS+3d, A1580 | 88d | 0d |
| A1750 |  | Instalación de Geotextil - Talud | 2d | 2023-09-25 | 2023-09-27 | A1710 SS+6d, A1590 | 65d | 0d |
|  | 4 | **Colocación de Roca** |  | 2023-08-31 | 2023-09-30 |  |  |  |
| A1760 |  | Colocación de roca de uña | 3d | 2023-08-31 | 2023-09-03 | A1740 SS+3d, A1600 | 88d | 16d |
| A1770 |  | Colocación de roca de talud | 2d | 2023-09-28 | 2023-09-30 | A1750 SS+3d, A1610 | 65d | 0d |

| ID | WBS | Activity | Duration | Start | Finish | Predecessors | Total float | Free float |
| --- | --- | --- | --- | --- | --- | --- | --- | --- |
|  | 5 | **Paquete 3** |  | 2023-06-01 | 2023-12-20 |  |  |  |
|  | 1 | **DI-PR-13-D-1** |  | 2023-06-01 | 2023-10-17 |  |  |  |
|  | 1 | **Excavaciones** |  | 2023-06-01 | 2023-07-09 |  |  |  |
| A1800 |  | Desbroce | 28d | 2023-06-01 | 2023-07-05 | A1050 | 0d |  |
| A1805 |  | Excavación de cimentación | 28d | 2023-06-01 | 2023-07-05 | A1800 SS | 0d |  |
| A1810 |  | Remoción Dique Existente | 28d | 2023-06-01 | 2023-07-05 | A1805 SS | 64d | 0d |
| A1815 |  | Excavación localizada - sobrexcavación | 28d | 2023-06-01 | 2023-07-05 | A1805 SS | 64d | 0d |
| A1820 |  | Perfilado y conformación de plataforma de fundación | 26d | 2023-06-05 | 2023-07-06 | A1805 SS+3d | 71d | 2d |
| A1830 |  | Excavación de uña | 26d | 2023-06-08 | 2023-07-09 | A1805 SS+6d | 0d |  |
|  | 2 | **Rellenos** |  | 2023-06-12 | 2023-10-17 |  |  |  |
| A1840 |  | Relleno con material granular | 74d | 2023-06-12 | 2023-09-10 | A1830 SS+3d | 0d |  |
| A1845 |  | Relleno con material seleccionado en sobreexcavación | 74d | 2023-06-12 | 2023-09-10 | A1840 SS | 17d | 0d |
| A1850 |  | Perfilado de Talud del dique | 74d | 2023-06-26 | 2023-09-24 | A1840 SS+12d | 0d |  |
| A1860 |  | Relleno sin compactar | 14d | 2023-09-21 | 2023-10-07 | A1900 | 23d | 0d |
| A1930 |  | Grava para drenaje | 3d | 2023-09-21 | 2023-09-24 | A1860 SS | 72d |  |
| A1870 |  | Relleno afirmado | 4d | 2023-10-12 | 2023-10-17 | A1910 | 37d | 0d |
|  | 3 | **Geotextil** |  | 2023-06-12 | 2023-09-13 |  |  |  |
| A1880 |  | Instalación de Geotextil - uña | 24d | 2023-06-12 | 2023-07-11 | A1830 SS+3d | 0d |  |
| A1890 |  | Instalación de Geotextil - Talud | 58d | 2023-07-04 | 2023-09-13 | A1850 SS+6d | 0d |  |
|  | 4 | **Colocación de Roca** |  | 2023-06-15 | 2023-10-12 |  |  |  |
| A1900 |  | Colocación de roca de uña | 80d | 2023-06-15 | 2023-09-21 | A1880 SS+3d | 0d |  |
| A1910 |  | Colocación de roca de talud | 80d | 2023-07-07 | 2023-10-12 | A1890 SS+3d | 0d |  |
|  | 2 | **DI-PR-13-D-2** |  | 2023-07-05 | 2023-10-19 |  |  |  |
|  | 1 | **Excavaciones** |  | 2023-07-05 | 2023-07-14 |  |  |  |
| A1940 |  | Desbroce | 2d | 2023-07-05 | 2023-07-07 | A1800 | 40d | 0d |
| A1945 |  | Excavación de cimentación | 2d | 2023-07-05 | 2023-07-07 | A1940 SS, A1805 | 40d | 0d |
| A1950 |  | Remoción Dique Existente | 2d | 2023-07-05 | 2023-07-07 | A1945 SS, A1810 | 64d | 0d |
| A1955 |  | Excavación localizada - sobrexcavación | 2d | 2023-07-05 | 2023-07-07 | A1945 SS, A1815 | 64d | 0d |
| A1960 |  | Perfilado y conformación de plataforma de fundación | 2d | 2023-07-08 | 2023-07-11 | A1945 SS+3d, A1820 | 69d | 0d |
| A1970 |  | Excavación de uña | 2d | 2023-07-12 | 2023-07-14 | A1945 SS+6d, A1830 | 42d | 0d |

| ID | WBS | Activity | Duration | Start | Finish | Predecessors | Total float | Free float |
| --- | --- | --- | --- | --- | --- | --- | --- | --- |
|  | 2 | **Rellenos** |  | 2023-09-11 | 2023-10-19 |  |  |  |
| A1980 |  | Relleno con material granular | 4d | 2023-09-11 | 2023-09-15 | A1970 SS+3d, A1840 | 0d |  |
| A1985 |  | Relleno con material seleccionado en sobreexcavación | 4d | 2023-09-11 | 2023-09-15 | A1980 SS, A1845 | 17d | 0d |
| A1990 |  | Perfilado de Talud del dique | 2d | 2023-09-25 | 2023-09-27 | A1980 SS+12d, A1850 | 4d | 0d |
| A2000 |  | Relleno sin compactar | 2d | 2023-10-07 | 2023-10-10 | A2040, A1860 | 23d | 0d |
| A2070 |  | Grava para drenaje | 2d | 2023-10-07 | 2023-10-10 | A1980, A2000 SS | 59d |  |
| A2010 |  | Relleno afirmado | 2d | 2023-10-17 | 2023-10-19 | A2050, A1870 | 37d | 0d |
|  | 3 | **Geotextil** |  | 2023-07-15 | 2023-10-04 |  |  |  |
| A2020 |  | Instalación de Geotextil - uña | 2d | 2023-07-15 | 2023-07-18 | A1970 SS+3d, A1880 | 52d | 0d |
| A2030 |  | Instalación de Geotextil - Talud | 2d | 2023-10-02 | 2023-10-04 | A1990 SS+6d, A1890 | 6d | 2d |
|  | 4 | **Colocación de Roca** |  | 2023-09-21 | 2023-10-17 |  |  |  |
| A2040 |  | Colocación de roca de uña | 7d | 2023-09-21 | 2023-09-29 | A2020 SS+3d, A1900 | 0d |  |
| A2050 |  | Colocación de roca de talud | 4d | 2023-10-12 | 2023-10-17 | A2030 SS+3d, A1910 | 0d |  |
|  | 3 | **DI-PR-13-D-3** |  | 2023-07-07 | 2023-10-21 |  |  |  |
|  | 1 | **Excavaciones** |  | 2023-07-07 | 2023-07-16 |  |  |  |
| A2100 |  | Desbroce | 2d | 2023-07-07 | 2023-07-09 | A1940 | 40d | 0d |
| A2105 |  | Excavación de cimentación | 2d | 2023-07-07 | 2023-07-09 | A2100 SS, A1945 | 40d | 0d |
| A2110 |  | Remoción Dique Existente | 2d | 2023-07-07 | 2023-07-09 | A2105 SS, A1950 | 64d | 0d |
| A2115 |  | Excavación localizada - sobrexcavación | 2d | 2023-07-07 | 2023-07-09 | A2105 SS, A1955 | 64d | 0d |
| A2120 |  | Perfilado y conformación de plataforma de fundación | 2d | 2023-07-11 | 2023-07-13 | A2105 SS+3d, A1960 | 69d | 0d |
| A2130 |  | Excavación de uña | 2d | 2023-07-14 | 2023-07-16 | A2105 SS+6d, A1970 | 42d | 0d |
|  | 2 | **Rellenos** |  | 2023-09-15 | 2023-10-21 |  |  |  |
| A2140 |  | Relleno con material granular | 2d | 2023-09-15 | 2023-09-17 | A2130 SS+3d, A1980 | 0d |  |
| A2145 |  | Relleno con material seleccionado en sobreexcavación | 2d | 2023-09-15 | 2023-09-17 | A2140 SS, A1985 | 17d | 0d |
| A2150 |  | Perfilado de Talud del dique | 2d | 2023-09-29 | 2023-10-01 | A2140 SS+12d, A1990 | 2d | 0d |
| A2160 |  | Relleno sin compactar | 2d | 2023-10-10 | 2023-10-12 | A2200, A2000 | 23d | 0d |
| A2230 |  | Grava para drenaje | 2d | 2023-10-10 | 2023-10-12 | A2140, A2160 SS | 57d |  |
| A2170 |  | Relleno afirmado | 2d | 2023-10-19 | 2023-10-21 | A2210, A2010 | 37d | 2d |

| ID | WBS | Activity | Duration | Start | Finish | Predecessors | Total float | Free float |
| --- | --- | --- | --- | --- | --- | --- | --- | --- |
|  | 3 | **Geotextil** |  | 2023-07-18 | 2023-10-08 |  |  |  |
| A2180 |  | Instalación de Geotextil - uña | 2d | 2023-07-18 | 2023-07-20 | A2130 SS+3d, A2020 | 52d | 0d |
| A2190 |  | Instalación de Geotextil - Talud | 2d | 2023-10-06 | 2023-10-08 | A2150 SS+6d, A2030 | 4d | 0d |
|  | 4 | **Colocación de Roca** |  | 2023-09-29 | 2023-10-19 |  |  |  |
| A2200 |  | Colocación de roca de uña | 3d | 2023-09-29 | 2023-10-03 | A2180 SS+3d, A2040 | 0d |  |
| A2210 |  | Colocación de roca de talud | 2d | 2023-10-17 | 2023-10-19 | A2190 SS+3d, A2050 | 0d |  |
|  | 4 | **DI-PR-16-D** |  | 2023-07-10 | 2023-10-26 |  |  |  |
|  | 1 | **Excavaciones** |  | 2023-07-10 | 2023-07-25 |  |  |  |
| A2260 |  | Desbroce | 8d | 2023-07-10 | 2023-07-19 | A2100 | 40d | 0d |
| A2265 |  | Excavación de cimentación | 8d | 2023-07-10 | 2023-07-19 | A2260 SS, A2105 | 40d | 0d |
| A2270 |  | Remoción Dique Existente | 8d | 2023-07-10 | 2023-07-19 | A2265 SS, A2110 | 64d | 0d |
| A2275 |  | Excavación localizada - sobrexcavación | 8d | 2023-07-10 | 2023-07-19 | A2265 SS, A2115 | 64d | 0d |
| A2280 |  | Perfilado y conformación de plataforma de fundación | 6d | 2023-07-13 | 2023-07-20 | A2265 SS+3d, A2120 | 69d | 2d |
| A2290 |  | Excavación de uña | 7d | 2023-07-17 | 2023-07-25 | A2265 SS+6d, A2130 | 42d | 0d |
|  | 2 | **Rellenos** |  | 2023-09-18 | 2023-10-26 |  |  |  |
| A2300 |  | Relleno con material granular | 4d | 2023-09-18 | 2023-09-22 | A2290 SS+3d, A2140 | 0d |  |
| A2305 |  | Relleno con material seleccionado en sobreexcavación | 4d | 2023-09-18 | 2023-09-22 | A2300 SS, A2145 | 17d | 0d |
| A2310 |  | Perfilado de Talud del dique | 5d | 2023-10-02 | 2023-10-07 | A2300 SS+12d, A2150 | 2d | 0d |
| A2320 |  | Relleno sin compactar | 4d | 2023-10-12 | 2023-10-17 | A2360, A2160 | 23d | 0d |
| A2390 |  | Grava para drenaje | 2d | 2023-10-12 | 2023-10-14 | A2320 SS, A2300 | 55d |  |
| A2330 |  | Relleno afirmado | 2d | 2023-10-24 | 2023-10-26 | A2370, A2170 | 35d | 4d |
|  | 3 | **Geotextil** |  | 2023-07-20 | 2023-10-13 |  |  |  |
| A2340 |  | Instalación de Geotextil - uña | 6d | 2023-07-20 | 2023-07-27 | A2290 SS+3d, A2180 | 52d | 2d |
| A2350 |  | Instalación de Geotextil - Talud | 4d | 2023-10-09 | 2023-10-13 | A2310 SS+6d, A2190 | 4d | 1d |

| ID | WBS | Activity | Duration | Start | Finish | Predecessors | Total float | Free float |
| --- | --- | --- | --- | --- | --- | --- | --- | --- |
|  | 4 | **Colocación de Roca** |  | 2023-10-03 | 2023-10-24 |  |  |  |
| A2360 |  | Colocación de roca de uña | 7d | 2023-10-03 | 2023-10-11 | A2340 SS+3d, A2200 | 0d |  |
| A2370 |  | Colocación de roca de talud | 4d | 2023-10-19 | 2023-10-24 | A2350 SS+3d, A2210 | 0d |  |
|  | 5 | **DI-PR-17-D** |  | 2023-07-19 | 2023-11-03 |  |  |  |
|  | 1 | **Excavaciones** |  | 2023-07-19 | 2023-08-15 |  |  |  |
| A2420 |  | Desbroce | 16d | 2023-07-19 | 2023-08-09 | A2260 | 40d | 0d |
| A2425 |  | Excavación de cimentación | 16d | 2023-07-19 | 2023-08-09 | A2420 SS, A2265 | 40d | 0d |
| A2430 |  | Remoción Dique Existente | 16d | 2023-07-19 | 2023-08-09 | A2425 SS, A2270 | 64d | 0d |
| A2435 |  | Excavación localizada - sobrexcavación | 16d | 2023-07-19 | 2023-08-09 | A2425 SS, A2275 | 64d | 0d |
| A2440 |  | Perfilado y conformación de plataforma de fundación | 14d | 2023-07-22 | 2023-08-10 | A2425 SS+3d, A2280 | 67d | 2d |
| A2450 |  | Excavación de uña | 15d | 2023-07-26 | 2023-08-15 | A2425 SS+6d, A2290 | 41d | 0d |
|  | 2 | **Rellenos** |  | 2023-09-22 | 2023-11-03 |  |  |  |
| A2460 |  | Relleno con material granular | 12d | 2023-09-22 | 2023-10-06 | A2450 SS+3d, A2300 | 0d |  |
| A2465 |  | Relleno con material seleccionado en sobreexcavación | 12d | 2023-09-22 | 2023-10-06 | A2460 SS, A2305 | 17d | 0d |
| A2470 |  | Perfilado de Talud del dique | 9d | 2023-10-07 | 2023-10-18 | A2460 SS+12d, A2310 | 2d | 0d |
| A2480 |  | Relleno sin compactar | 8d | 2023-10-19 | 2023-10-28 | A2520, A2320 | 21d | 0d |
| A2550 |  | Grava para drenaje | 2d | 2023-10-19 | 2023-10-21 | A2460, A2480 SS | 49d |  |
| A2490 |  | Relleno afirmado | 2d | 2023-10-31 | 2023-11-03 | A2530, A2330 | 31d | 2d |
|  | 3 | **Geotextil** |  | 2023-08-01 | 2023-10-24 |  |  |  |
| A2500 |  | Instalación de Geotextil - uña | 14d | 2023-08-01 | 2023-08-17 | A2450 SS+3d, A2340 | 50d | 2d |
| A2510 |  | Instalación de Geotextil - Talud | 8d | 2023-10-14 | 2023-10-24 | A2470 SS+6d, A2350 | 3d |  |
|  | 4 | **Colocación de Roca** |  | 2023-10-11 | 2023-10-31 |  |  |  |
| A2520 |  | Colocación de roca de uña | 7d | 2023-10-11 | 2023-10-19 | A2500 SS+3d, A2360 | 0d |  |
| A2530 |  | Colocación de roca de talud | 6d | 2023-10-24 | 2023-10-31 | A2510 SS+3d, A2370 | 0d |  |

| ID | WBS | Activity | Duration | Start | Finish | Predecessors | Total float | Free float |
| --- | --- | --- | --- | --- | --- | --- | --- | --- |
|  | 6 | **DI-PR-18-D-1** |  | 2023-08-09 | 2023-11-08 |  |  |  |
|  | 1 | **Excavaciones** |  | 2023-08-09 | 2023-08-19 |  |  |  |
| A2580 |  | Desbroce | 4d | 2023-08-09 | 2023-08-13 | A2420 | 40d | 0d |
| A2585 |  | Excavación de cimentación | 4d | 2023-08-09 | 2023-08-13 | A2580 SS, A2425 | 40d | 0d |
| A2590 |  | Remoción Dique Existente | 4d | 2023-08-09 | 2023-08-13 | A2585 SS, A2430 | 64d | 0d |
| A2595 |  | Excavación localizada - sobrexcavación | 4d | 2023-08-09 | 2023-08-13 | A2585 SS, A2435 | 64d | 0d |
| A2600 |  | Perfilado y conformación de plataforma de fundación | 2d | 2023-08-12 | 2023-08-15 | A2585 SS+3d, A2440 | 65d | 2d |
| A2610 |  | Excavación de uña | 3d | 2023-08-16 | 2023-08-19 | A2585 SS+6d, A2450 | 40d | 0d |
|  | 2 | **Rellenos** |  | 2023-10-06 | 2023-11-08 |  |  |  |
| A2620 |  | Relleno con material granular | 4d | 2023-10-06 | 2023-10-11 | A2610 SS+3d, A2460 | 0d |  |
| A2625 |  | Relleno con material seleccionado en sobreexcavación | 2d | 2023-10-06 | 2023-10-08 | A2620 SS, A2465 | 17d | 2d |
| A2630 |  | Perfilado de Talud del dique | 2d | 2023-10-20 | 2023-10-22 | A2620 SS+12d, A2470 | 0d |  |
| A2640 |  | Relleno sin compactar | 2d | 2023-10-28 | 2023-10-31 | A2680, A2480 | 21d | 0d |
| A2710 |  | Grava para drenaje | 2d | 2023-10-28 | 2023-10-31 | A2620, A2640 SS | 41d |  |
| A2650 |  | Relleno afirmado | 2d | 2023-11-06 | 2023-11-08 | A2690, A2490 | 29d | 20d |
|  | 3 | **Geotextil** |  | 2023-08-19 | 2023-10-29 |  |  |  |
| A2660 |  | Instalación de Geotextil - uña | 3d | 2023-08-19 | 2023-08-23 | A2610 SS+3d, A2500 | 48d | 1d |
| A2670 |  | Instalación de Geotextil - Talud | 2d | 2023-10-27 | 2023-10-29 | A2630 SS+6d, A2510 | 0d |  |
|  | 4 | **Colocación de Roca** |  | 2023-10-19 | 2023-11-05 |  |  |  |
| A2680 |  | Colocación de roca de uña | 5d | 2023-10-19 | 2023-10-25 | A2660 SS+3d, A2520 | 0d |  |
| A2690 |  | Colocación de roca de talud | 4d | 2023-10-31 | 2023-11-05 | A2670 SS+3d, A2530 | 0d |  |
|  | 7 | **DI-PR-18-D-2** |  | 2023-08-14 | 2023-12-05 |  |  |  |
|  | 1 | **Excavaciones** |  | 2023-08-14 | 2023-09-15 |  |  |  |
| A2740 |  | Desbroce | 22d | 2023-08-14 | 2023-09-09 | A2580 | 40d | 0d |
| A2745 |  | Excavación de cimentación | 22d | 2023-08-14 | 2023-09-09 | A2740 SS, A2585 | 40d | 0d |
| A2750 |  | Remoción Dique Existente | 22d | 2023-08-14 | 2023-09-09 | A2745 SS, A2590 | 64d | 0d |
| A2755 |  | Excavación localizada - sobrexcavación | 22d | 2023-08-14 | 2023-09-09 | A2745 SS, A2595 | 64d | 0d |
| A2760 |  | Perfilado y conformación de plataforma de fundación | 21d | 2023-08-17 | 2023-09-12 | A2745 SS+3d, A2600 | 63d | 1d |
| A2770 |  | Excavación de uña | 21d | 2023-08-21 | 2023-09-15 | A2745 SS+6d, A2610 | 40d | 0d |

| ID | WBS | Activity | Duration | Start | Finish | Predecessors | Total float | Free float |
| --- | --- | --- | --- | --- | --- | --- | --- | --- |
|  | 2 | **Rellenos** |  | 2023-10-11 | 2023-12-05 |  |  |  |
| A2780 |  | Relleno con material granular | 22d | 2023-10-11 | 2023-11-07 | A2770 SS+3d, A2620 | 0d |  |
| A2785 |  | Relleno con material seleccionado en sobreexcavación | 22d | 2023-10-11 | 2023-11-07 | A2780 SS, A2625 | 15d | 0d |
| A2790 |  | Perfilado de Talud del dique | 13d | 2023-10-25 | 2023-11-10 | A2780 SS+12d, A2630 | 0d |  |
| A2800 |  | Relleno sin compactar | 9d | 2023-11-22 | 2023-12-02 | A2840, A2640 | 3d | 0d |
| A2870 |  | Grava para drenaje | 2d | 2023-11-22 | 2023-11-24 | A2800 SS, A2780 | 21d |  |
| A2810 |  | Relleno afirmado | 3d | 2023-12-01 | 2023-12-05 | A2850, A2650 | 9d |  |
|  | 3 | **Geotextil** |  | 2023-08-24 | 2023-11-14 |  |  |  |
| A2820 |  | Instalación de Geotextil - uña | 20d | 2023-08-24 | 2023-09-17 | A2770 SS+3d, A2660 | 49d | 2d |
| A2830 |  | Instalación de Geotextil - Talud | 10d | 2023-11-02 | 2023-11-14 | A2790 SS+6d, A2670 | 0d |  |
|  | 4 | **Colocación de Roca** |  | 2023-10-25 | 2023-12-01 |  |  |  |
| A2840 |  | Colocación de roca de uña | 23d | 2023-10-25 | 2023-11-22 | A2820 SS+3d, A2680 | 0d |  |
| A2850 |  | Colocación de roca de talud | 22d | 2023-11-06 | 2023-12-01 | A2830 SS+3d, A2690 | 0d |  |
|  | 8 | **DI-PR-19A-D-1** |  | 2023-09-09 | 2023-12-20 |  |  |  |
|  | 1 | **Excavaciones** |  | 2023-09-09 | 2023-10-08 |  |  |  |
| A2900 |  | Desbroce | 21d | 2023-09-09 | 2023-10-04 | A2740 | 40d | 0d |
| A2905 |  | Excavación de cimentación | 21d | 2023-09-09 | 2023-10-04 | A2900 SS, A2745 | 40d | 0d |
| A2910 |  | Remoción Dique Existente | 21d | 2023-09-09 | 2023-10-04 | A2905 SS, A2750 | 64d |  |
| A2915 |  | Excavación localizada - sobrexcavación | 21d | 2023-09-09 | 2023-10-04 | A2905 SS, A2755 | 64d |  |
| A2920 |  | Perfilado y conformación de plataforma de fundación | 20d | 2023-09-13 | 2023-10-06 | A2905 SS+3d, A2760 | 62d |  |
| A2930 |  | Excavación de uña | 19d | 2023-09-16 | 2023-10-08 | A2905 SS+6d, A2770 | 40d | 0d |
|  | 2 | **Rellenos** |  | 2023-11-07 | 2023-12-20 |  |  |  |
| A2940 |  | Relleno con material granular | 21d | 2023-11-07 | 2023-12-01 | A2930 SS+3d, A2780 | 0d |  |
| A2945 |  | Relleno con material seleccionado en sobreexcavación | 21d | 2023-11-07 | 2023-12-01 | A2940 SS, A2785 | 15d |  |
| A2950 |  | Perfilado de Talud del dique | 12d | 2023-11-21 | 2023-12-05 | A2940 SS+12d, A2790 | 0d |  |
| A2960 |  | Relleno sin compactar | 11d | 2023-12-06 | 2023-12-20 | A3000, A2800 | 0d |  |
| A3030 |  | Grava para drenaje | 2d | 2023-12-06 | 2023-12-08 | A2960 SS, A2940 | 9d |  |
| A2970 |  | Relleno afirmado | 3d | 2023-12-16 | 2023-12-20 | A3010, A2810 | 0d |  |

| ID | WBS | Activity | Duration | Start | Finish | Predecessors | Total float | Free float |
| --- | --- | --- | --- | --- | --- | --- | --- | --- |
|  | 3 | **Geotextil** |  | 2023-09-20 | 2023-12-13 |  |  |  |
| A2980 |  | Instalación de Geotextil - uña | 18d | 2023-09-20 | 2023-10-11 | A2930 SS+3d, A2820 | 50d |  |
| A2990 |  | Instalación de Geotextil - Talud | 12d | 2023-11-28 | 2023-12-13 | A2950 SS+6d, A2830 | 0d |  |
|  | 4 | **Colocación de Roca** |  | 2023-11-22 | 2023-12-16 |  |  |  |
| A3000 |  | Colocación de roca de uña | 12d | 2023-11-22 | 2023-12-06 | A2980 SS+3d, A2840 | 0d |  |
| A3010 |  | Colocación de roca de talud | 12d | 2023-12-01 | 2023-12-16 | A2990 SS+3d, A2850 | 0d |  |
|  | 9 | **DI-PR-19A-D-2** |  | 2023-06-01 | 2023-10-10 |  |  |  |
|  | 1 | **Excavaciones** |  | 2023-06-01 | 2023-08-18 |  |  |  |
| A3060 |  | Desbroce | 62d | 2023-06-01 | 2023-08-16 | A1050 | 8d | 0d |
| A3065 |  | Excavación de cimentación | 62d | 2023-06-01 | 2023-08-16 | A3060 SS | 8d | 0d |
| A3070 |  | Remoción Dique Existente | 62d | 2023-06-01 | 2023-08-16 | A3065 SS | 41d | 0d |
| A3075 |  | Excavación localizada - sobrexcavación | 62d | 2023-06-01 | 2023-08-16 | A3065 SS | 41d | 0d |
| A3080 |  | Perfilado y conformación de plataforma de fundación | 60d | 2023-06-05 | 2023-08-17 | A3065 SS+3d | 44d | 2d |
| A3090 |  | Excavación de uña | 58d | 2023-06-08 | 2023-08-18 | A3065 SS+6d | 11d | 0d |
|  | 2 | **Rellenos** |  | 2023-06-12 | 2023-10-10 |  |  |  |
| A3100 |  | Relleno con material granular | 60d | 2023-06-12 | 2023-08-24 | A3090 SS+3d | 13d | 0d |
| A3105 |  | Relleno con material seleccionado en sobreexcavación | 60d | 2023-06-12 | 2023-08-24 | A3100 SS | 41d | 2d |
| A3110 |  | Perfilado de Talud del dique | 50d | 2023-06-26 | 2023-08-26 | A3100 SS+12d | 34d | 0d |
| A3120 |  | Relleno sin compactar | 30d | 2023-09-05 | 2023-10-10 | A3160 | 59d | 0d |
| A3190 |  | Grava para drenaje | 6d | 2023-09-05 | 2023-09-12 | A3120 SS, A3100 | 64d | 24d |
| A3130 |  | Relleno afirmado | 8d | 2023-09-07 | 2023-09-16 | A3170 | 69d | 21d |
|  | 3 | **Geotextil** |  | 2023-06-12 | 2023-09-01 |  |  |  |
| A3140 |  | Instalación de Geotextil - uña | 65d | 2023-06-12 | 2023-08-30 | A3090 SS+3d | 11d | 0d |
| A3150 |  | Instalación de Geotextil - Talud | 48d | 2023-07-04 | 2023-09-01 | A3110 SS+6d | 43d | 0d |

| ID | WBS | Activity | Duration | Start | Finish | Predecessors | Total float | Free float |
| --- | --- | --- | --- | --- | --- | --- | --- | --- |
|  | 4 | **Colocación de Roca** |  | 2023-06-15 | 2023-09-07 |  |  |  |
| A3160 |  | Colocación de roca de uña | 66d | 2023-06-15 | 2023-09-05 | A3140 SS+3d | 12d | 0d |
| A3170 |  | Colocación de roca de talud | 50d | 2023-07-07 | 2023-09-07 | A3150 SS+3d | 43d | 0d |
|  | 10 | **DI-PR-19A-D-3** |  | 2023-08-16 | 2023-11-01 |  |  |  |
|  | 1 | **Excavaciones** |  | 2023-08-16 | 2023-10-04 |  |  |  |
| A3220 |  | Desbroce | 38d | 2023-08-16 | 2023-09-30 | A3060 | 8d | 0d |
| A3225 |  | Excavación de cimentación | 38d | 2023-08-16 | 2023-09-30 | A3220 SS, A3065 | 8d | 0d |
| A3230 |  | Remoción Dique Existente | 38d | 2023-08-16 | 2023-09-30 | A3225 SS, A3070 | 41d | 0d |
| A3235 |  | Excavación localizada - sobrexcavación | 38d | 2023-08-16 | 2023-09-30 | A3225 SS, A3075 | 41d | 0d |
| A3240 |  | Perfilado y conformación de plataforma de fundación | 36d | 2023-08-19 | 2023-10-01 | A3225 SS+3d, A3080 | 42d | 2d |
| A3250 |  | Excavación de uña | 35d | 2023-08-23 | 2023-10-04 | A3225 SS+6d, A3090 | 11d | 0d |
|  | 2 | **Rellenos** |  | 2023-08-26 | 2023-11-01 |  |  |  |
| A3260 |  | Relleno con material granular | 37d | 2023-08-26 | 2023-10-10 | A3250 SS+3d, A3100 | 11d | 0d |
| A3265 |  | Relleno con material seleccionado en sobreexcavación | 37d | 2023-08-26 | 2023-10-10 | A3260 SS, A3105 | 39d | 1d |
| A3270 |  | Perfilado de Talud del dique | 26d | 2023-09-11 | 2023-10-11 | A3260 SS+12d, A3110 | 22d | 0d |
| A3280 |  | Relleno sin compactar | 19d | 2023-10-10 | 2023-11-01 | A3320, A3190 | 40d | 0d |
| A3350 |  | Grava para drenaje | 4d | 2023-10-10 | 2023-10-14 | A3260, A3280 SS | 42d | 34d |
| A3290 |  | Relleno afirmado | 6d | 2023-10-11 | 2023-10-18 | A3330, A3130 | 48d | 38d |
|  | 3 | **Geotextil** |  | 2023-08-31 | 2023-10-08 |  |  |  |
| A3300 |  | Instalación de Geotextil - uña | 32d | 2023-08-31 | 2023-10-07 | A3250 SS+3d, A3140 | 11d | 1d |
| A3310 |  | Instalación de Geotextil - Talud | 18d | 2023-09-18 | 2023-10-08 | A3270 SS+6d, A3150 | 30d | 0d |
|  | 4 | **Colocación de Roca** |  | 2023-09-05 | 2023-10-11 |  |  |  |
| A3320 |  | Colocación de roca de uña | 30d | 2023-09-05 | 2023-10-10 | A3300 SS+3d, A3160 | 12d | 0d |
| A3330 |  | Colocación de roca de talud | 17d | 2023-09-21 | 2023-10-11 | A3310 SS+3d, A3170 | 31d | 0d |

| ID | WBS | Activity | Duration | Start | Finish | Predecessors | Total float | Free float |
| --- | --- | --- | --- | --- | --- | --- | --- | --- |
|  | 11 | **DI-PR-19B-D** |  | 2023-09-30 | 2023-12-10 |  |  |  |
|  | 1 | **Excavaciones** |  | 2023-09-30 | 2023-11-05 |  |  |  |
| A3380 |  | Desbroce | 26d | 2023-09-30 | 2023-10-31 | A3220 | 8d | 0d |
| A3385 |  | Excavación de cimentación | 26d | 2023-09-30 | 2023-10-31 | A3380 SS, A3225 | 8d | 0d |
| A3390 |  | Remoción Dique Existente | 26d | 2023-09-30 | 2023-10-31 | A3385 SS, A3230 | 41d |  |
| A3395 |  | Excavación localizada - sobrexcavación | 26d | 2023-09-30 | 2023-10-31 | A3385 SS, A3235 | 41d |  |
| A3400 |  | Perfilado y conformación de plataforma de fundación | 24d | 2023-10-04 | 2023-11-01 | A3385 SS+3d, A3240 | 40d |  |
| A3410 |  | Excavación de uña | 24d | 2023-10-07 | 2023-11-05 | A3385 SS+6d, A3250 | 8d | 0d |
|  | 2 | **Rellenos** |  | 2023-10-11 | 2023-12-10 |  |  |  |
| A3420 |  | Relleno con material granular | 20d | 2023-10-11 | 2023-11-04 | A3410 SS+3d, A3260 | 10d | 0d |
| A3425 |  | Relleno con material seleccionado en sobreexcavación | 20d | 2023-10-11 | 2023-11-04 | A3420 SS, A3265 | 38d |  |
| A3430 |  | Perfilado de Talud del dique | 15d | 2023-10-25 | 2023-11-12 | A3420 SS+12d, A3270 | 10d | 0d |
| A3440 |  | Relleno sin compactar | 13d | 2023-11-24 | 2023-12-10 | A3350, A3480 | 8d | 0d |
| A3510 |  | Grava para drenaje | 3d | 2023-11-24 | 2023-11-28 | A3420, A3440 SS | 18d |  |
| A3450 |  | Relleno afirmado | 4d | 2023-12-02 | 2023-12-07 | A3490, A3290 | 10d |  |
|  | 3 | **Geotextil** |  | 2023-10-11 | 2023-11-19 |  |  |  |
| A3460 |  | Instalación de Geotextil - uña | 8d | 2023-10-11 | 2023-10-20 | A3410 SS+3d, A3300 | 8d | 0d |
| A3470 |  | Instalación de Geotextil - Talud | 15d | 2023-11-02 | 2023-11-19 | A3430 SS+6d, A3310 | 10d | 0d |
|  | 4 | **Colocación de Roca** |  | 2023-10-14 | 2023-12-02 |  |  |  |
| A3480 |  | Colocación de roca de uña | 34d | 2023-10-14 | 2023-11-24 | A3460 SS+3d, A3320 | 8d | 0d |
| A3490 |  | Colocación de roca de talud | 23d | 2023-11-06 | 2023-12-02 | A3470 SS+3d, A3330 | 10d | 0d |
|  | 6 | **Obras Civiles** |  | 2023-04-25 | 2023-11-09 |  |  |  |
| A3520 |  | Obras Civiles - Paquete 02 (11 estructuras) | 100d | 2023-04-25 | 2023-08-24 | A1190 SS+3d | 98d | 33d |
| A3530 |  | Obras Civiles - Paquete 03 (13 Estructuras) | 130d | 2023-06-05 | 2023-11-09 | A1800 SS+3d | 34d |  |

| ID | WBS | Activity | Duration | Start | Finish | Predecessors | Total float | Free float |
| --- | --- | --- | --- | --- | --- | --- | --- | --- |
|  | 7 | **Accesos** |  | 2023-08-24 | 2023-12-17 |  |  |  |
| A3540 |  | Accesos - Paquete 02 Frente 2 (04 Losas) | 48d | 2023-08-24 | 2023-10-20 | A1380 | 2d | 0d |
| A3550 |  | Accesos - Paquete 03 Frente 2 (04 Losas) | 48d | 2023-10-20 | 2023-12-17 | A3540 | 2d |  |
|  | 8 | **Señalización** |  | 2023-04-01 | 2023-12-19 |  |  |  |
| A3560 |  | Señalización de Obra | 215d | 2023-04-01 | 2023-12-19 | A1010 | 1d |  |
|  | 9 | **Calidad** |  | 2023-04-01 | 2023-12-19 |  |  |  |
| A3570 |  | Control de Calidad | 215d | 2023-04-01 | 2023-12-19 | A1010 | 1d |  |
